Schedule from MS Project, 2009-11-16 to 2015-01-30, 7 hours a day.
Microsoft

## Calendars

- Standard: Mon-Fri 09:00-12:00, 14:00-18:00; Sat-Sun off. Exceptions (off unless hours are given): 2013-12-23 to 2014-01-03, 2014-08-04 to 2014-08-29.
- Sans vacances: Mon-Fri 09:00-12:00, 14:00-18:00; Sat-Sun off.

## Resources

| Resource |
| --- |
| 4s |
| AJE |
| PLE |
| JCPE |
| 0.2AJE |

## Schedule

| ID | WBS | Task | Type | Duration | Start | Finish | Predecessors | Total slack | Free slack | Constraint | Calendar | Resources | Work |
| --- | --- | --- | --- | --- | --- | --- | --- | --- | --- | --- | --- | --- | --- |
| 1 | 1 | **CDR** |  | 101d | 2013-09-30 | 2014-03-03 |  | 0d |  |  |  |  |  |
| 2 | 1.1 | LFR data package delivery to LESIA | milestone, manual | 0d | 2013-09-30 | 2013-09-30 |  |  |  |  |  |  |  |
| 3 | 1.2 | RPW data package delivery | milestone, manual | 0d | 2013-12-20 | 2013-12-20 |  |  |  |  |  |  |  |
| 4 | 1.3 | CDR kick off | manual | 2d | 2014-01-22 | 2014-01-23 |  |  |  |  |  |  |  |
| 5 | 1.4 | Q/R meeting | manual | 4d | 2014-02-11 | 2014-02-14 |  |  |  |  |  |  |  |
| 6 | 1.5 | Report delivery | milestone, manual | 0d | 2014-02-28 | 2014-02-28 |  |  |  |  |  |  |  |
| 7 | 1.6 | Director board | manual | 1d | 2014-03-03 | 2014-03-03 |  |  |  |  |  |  |  |
| 8 | 2 | **ESA due dates** |  | 321d | 2013-09-26 | 2015-01-30 |  | 0d |  |  |  |  |  |
| 9 | 2.1 | STM delivery to ESA | milestone, manual | 0d | 2013-09-26 | 2013-09-26 |  |  |  |  |  |  |  |
| 10 | 2.2 | EM delivery to ESA | milestone, manual | 0d | 2014-07-01 | 2014-07-01 |  |  |  |  |  |  |  |
| 11 | 2.3 | FM delivery to ESA | milestone, manual | 0d | 2015-01-30 | 2015-01-30 |  |  |  |  |  |  |  |
| 12 | 3 | EM delivery to LESIA |  | 2d | 2009-11-16 | 2009-11-17 |  | 1327d |  |  |  |  |  |
| 13 | 4 | **QM additional developments** |  | 1191.14d | 2009-11-16 | 2014-06-24 |  | 137.86d |  |  |  |  | 643h |
| 14 | 4.1 | **Switch evaluation** |  | 30d | 2013-12-16 | 2014-02-07 |  | 121d | 15d |  |  |  | 98h |
| 15 | 4.1.1 | Switches delivery | milestone | 0d | 2014-01-06 | 2014-01-06 |  | 131d | 0d | start no earlier than 2014-01-06 |  |  |  |
| 16 | 4.1.2 | PCB design |  | 1w | 2013-12-16 | 2013-12-20 |  | 121d | 0d | start no earlier than 2013-12-16 |  | AJE | 35h |
| 17 | 4.1.3 | Manufacturing |  | 2w | 2013-12-23 | 2014-01-03 | 16 | 131d | 0d |  | Sans vacances |  |  |
| 18 | 4.1.4 | Board population |  | 1w | 2014-01-20 | 2014-01-24 | 15, 17 | 131d | 0d |  |  | AJE [80%] | 28h |
| 19 | 4.1.5 | Tests |  | 1w | 2014-01-27 | 2014-02-07 | 18 | 131d |  |  |  | AJE | 35h |
| 20 | 4.2 | **PreQM** |  | 1191.14d | 2009-11-16 | 2014-06-24 |  | 137.86d |  |  |  |  | 545h |
| 21 | 4.2.1 | PCB design |  | 2w | 2014-01-06 | 2014-01-17 | 16 | 130d | 0d | start no earlier than 2013-12-16 |  | AJE | 70h |
| 22 | 4.2.2 | PCB layout |  | 1w | 2014-01-28 | 2014-02-03 | 21 | 129d | 0d |  |  | AJE | 35h |
| 23 | 4.2.3 | PCB manufacturing |  | 2w | 2014-02-04 | 2014-02-17 | 22 | 147d | 0d |  | Sans vacances |  |  |
| 24 | 4.2.4 | **PreQM1** |  | 1191.14d | 2009-11-16 | 2014-06-24 |  | 137.86d |  |  |  |  | 154h |
| 25 | 4.2.4.1 | RAM delivery | milestone | 0d | 2009-11-16 | 2009-11-16 |  | 1279.57d | 1141.71d |  |  |  |  |
| 26 | 4.2.4.2 | Socket procurement |  | 8w | 2013-12-12 | 2014-02-05 |  | 206.57d | 48.71d | start no earlier than 2013-12-12 | Sans vacances |  |  |
| 27 | 4.2.4.3 | Board population (step 1) |  | 3w | 2014-02-18 | 2014-04-15 | 23 | 137.86d | 0d |  |  | AJE [80%] | 84h |
| 28 | 4.2.4.4 | Tests |  | 2w | 2014-04-15 | 2014-06-24 | 27, 25, 26 | 137.86d |  |  |  | AJE | 70h |
| 29 | 4.2.5 | Test equipments development |  | 4w | 2014-01-20 | 2014-02-28 | 21 | 151.29d | 25d |  |  | PLE [50%] | 70h |

Notes:
- 29: ADC emulator...

| ID | WBS | Task | Type | Duration | Start | Finish | Predecessors | Total slack | Free slack | Constraint | Calendar | Resources | Work |
| --- | --- | --- | --- | --- | --- | --- | --- | --- | --- | --- | --- | --- | --- |
| 30 | 4.2.6 | **PreQM2** |  | 149.71d | 2013-10-01 | 2014-05-12 |  | 0d |  |  |  |  | 216h |
| 31 | 4.2.6.1 | RTAX4000D PROTO order | milestone | 0d | 2013-10-01 | 2013-10-01 |  | 0d |  | must start on 2013-10-01 | Sans vacances |  |  |
| 32 | 4.2.6.2 | RTAX4000D PROTO procurement |  | 16w | 2013-10-01 | 2014-01-20 | 31 | 190.29d | 24.71d |  | Sans vacances |  |  |
| 33 | 4.2.6.3 | VHDL preliminary design delivery | milestone | 0d | 2014-02-03 | 2014-02-03 |  | 145.57d | 0d | start no earlier than 2014-02-03 |  |  |  |
| 34 | 4.2.6.4 | VHDL design validation |  | 2w | 2014-02-03 | 2014-02-14 | 33 | 145.57d | 0d |  |  | PLE | 70h |
| 35 | 4.2.6.5 | VHDL design need date | milestone | 0d | 2014-02-14 | 2014-02-14 | 34 | 145.57d | 0d |  |  |  |  |
| 36 | 4.2.6.6 | FPGA programming + delivery |  | 2w | 2014-02-24 | 2014-03-10 | 35SS+1.14w, 32 | 165.57d | 19.29d |  | Sans vacances |  |  |
| 37 | 4.2.6.7 | Board population (step 2) |  | 2w | 2014-03-24 | 2014-04-04 | 23 | 126.29d | 0d |  |  | AJE [80%] | 56h |
| 38 | 4.2.6.8 | Tests |  | 4w | 2014-04-07 | 2014-05-12 | 29, 37, 36 | 126.29d |  |  |  | PLE [50%]; AJE [50%] | 90h |
| 39 | 5 | **QM** |  | 103d | 2014-03-03 | 2014-07-23 |  | 116d |  |  |  |  | 161h |
| 40 | 5.1 | Kick-off |  | 1d | 2014-03-03 | 2014-03-03 | 14 | 116d | 0d | start no earlier than 2014-03-03 |  |  |  |
| 41 | 5.2 | Design (Schematics) |  | 2w | 2014-03-04 | 2014-03-17 | 40 | 116d | 0d |  |  | AJE [80%]; PLE [20%] | 70h |
| 42 | 5.3 | Layout (subcontractor) |  | 3w | 2014-03-18 | 2014-04-07 | 41 | 116d | 0d |  |  |  |  |
| 43 | 5.4 | Layout refinement with subcontractor |  | 1w | 2014-04-08 | 2014-04-14 | 42 | 116d | 0d |  |  | AJE [20%] | 7h |
| 44 | 5.5 | PCB manufacturing |  | 8w | 2014-04-15 | 2014-06-09 | 43 | 136d | 0d |  | Sans vacances |  |  |
| 45 | 5.6 | QM parts need date | milestone | 0d | 2014-06-06 | 2014-06-06 | 47SS-1.14d | 149.14d |  |  |  |  |  |
| 46 | 5.7 | FPGA programming (+test) |  | 2w | 2014-05-12 | 2014-05-26 | 30 | 126.29d | 10.29d |  |  | PLE [20%] | 14h |
| 47 | 5.8 | Board population |  | 2w | 2014-06-10 | 2014-06-23 | 44, 46 | 116d | 0d |  |  |  |  |
| 48 | 5.9 | Acceptance Hardware |  | 2w | 2014-06-24 | 2014-07-07 | 47 | 116d | 0d |  |  | AJE [50%] | 35h |
| 49 | 5.10 | Acceptance Software |  | 2w | 2014-07-08 | 2014-07-21 | 48 | 116d | 0d |  |  | PLE [50%] | 35h |
| 50 | 5.11 | QM delivery to LESIA |  | 2d | 2014-07-22 | 2014-07-23 | 49 | 116d |  |  |  |  |  |
| 51 | 6 | **FM** |  | 92.57d | 2014-09-01 | 2015-01-07 |  | 16.43d |  |  |  |  |  |
| 52 | 6.1 | Kick-off |  | 1.14d | 2014-09-01 | 2014-09-02 |  | 16.43d | 0d | start no earlier than 2014-09-01 |  |  |  |
| 53 | 6.2 | Layout |  | 4.57w | 2014-09-02 | 2014-10-02 | 52 | 16.43d | 0d |  |  |  |  |
| 54 | 6.3 | PCB manufacturing |  | 9.14w | 2014-10-03 | 2014-12-05 | 53 | 16.43d | 0d |  |  |  |  |
| 55 | 6.4 | FM parts need date | milestone | 0d | 2014-12-04 | 2014-12-04 | 57SS-1.14d | 40.43d |  |  |  |  |  |
| 56 | 6.5 | FPGA programming (+test) |  | 2.29w | 2014-11-12 | 2014-11-27 | 57SS-3.43w | 45d |  |  |  |  |  |
| 57 | 6.6 | Board population |  | 4.57w | 2014-12-05 | 2015-01-07 | 54 | 16.43d | 0d |  |  |  |  |
| 58 | 6.7 | Acceptance Hardware |  | 2.29w | 2014-12-05 | 2014-12-23 | 54 | 16.43d | 0d |  |  |  |  |
| 59 | 6.8 | Acceptance Software |  | 2.29w | 2014-12-23 | 2015-01-07 | 58 | 16.43d |  |  |  |  |  |
| 60 | 6.9 | FM delivery to LESIA |  | 2.29d | 2014-12-23 | 2014-12-25 | 58 | 25.57d |  |  |  |  |  |
